# 施工横道图

Schedule from MS Project, 2004-03-15 to 2004-08-11.
topwip

## Calendars

- 标准: Mon-Sun 08:00-12:00, 13:00-17:00.

## Schedule

| ID | WBS | Task | Duration | Start | Finish | Predecessors | Baseline start | Baseline finish | Baseline duration | Total slack | Free slack | Constraint |
| --- | --- | --- | --- | --- | --- | --- | --- | --- | --- | --- | --- | --- |
| 1 | 1 | **总工期** | 150d | 2004-03-15 | 2004-08-11 |  | 2004-03-02 | 2004-03-02 | 1d? | 0d |  |  |
| 2 | 1.1 | 施工准备 | 10d | 2004-03-15 | 2004-03-24 |  | 2004-03-02 | 2004-03-02 | 1d? | 0d |  | start no earlier than 2004-03-15 |
| 3 | 1.2 | **第一施工区（1~5层）** | 136d | 2004-03-17 | 2004-07-30 |  | 2004-03-02 | 2004-03-02 | 1d? | 10d |  |  |
| 4 | 1.2.1 | 新墙砌筑 | 15d | 2004-03-18 | 2004-04-01 | 2SS+3d |  |  |  | 2d | 0d |  |
| 5 | 1.2.2 | 墙面抹灰 | 20d | 2004-03-23 | 2004-04-11 | 4SS+5d |  |  |  | 2d | 0d |  |
| 6 | 1.2.3 | 隔断墙及墙面龙骨施工 | 30d | 2004-04-12 | 2004-05-11 | 5 |  |  |  | 65d |  |  |
| 7 | 1.2.4 | 天棚龙骨 | 35d | 2004-03-28 | 2004-05-01 | 5SS+5d |  |  |  | 63d | 0d |  |
| 8 | 1.2.5 | 天棚面层施工 | 32d | 2004-04-12 | 2004-05-13 | 7SS+15d |  |  |  | 63d |  |  |
| 9 | 1.2.6 | 墙面石材粘贴（干挂）施工 | 45d | 2004-04-12 | 2004-05-26 | 5 |  |  |  | 2d | 0d |  |
| 10 | 1.2.7 | 墙面瓷砖粘贴施工 | 25d | 2004-04-12 | 2004-05-06 | 5 |  |  |  | 40d | 0d |  |
| 11 | 1.2.8 | 软包墙面施工 | 25d | 2004-06-11 | 2004-07-05 | 12SS+40d |  |  |  | 10d |  |  |
| 12 | 1.2.9 | 木质板材墙面装饰施工 | 50d | 2004-05-02 | 2004-06-20 | 9SS+20d |  |  |  | 2d | 0d |  |
| 13 | 1.2.10 | 墙面进口立邦漆涂刷施工 | 30d | 2004-05-07 | 2004-06-05 | 10 |  |  |  | 40d |  |  |
| 14 | 1.2.11 | 玻璃隔断墙施工 | 45d | 2004-04-27 | 2004-06-10 | 9SS+15d |  |  |  | 35d |  |  |
| 15 | 1.2.12 | 墙面壁纸施工 | 25d | 2004-05-27 | 2004-06-20 | 12SS+25d |  |  |  | 25d |  |  |
| 16 | 1.2.13 | 墙面不锈钢饰面 | 15d | 2004-05-12 | 2004-05-26 | 12SS+10d |  |  |  | 50d |  |  |
| 17 | 1.2.14 | 卫生间防水施工 | 20d | 2004-04-02 | 2004-04-21 | 4 |  |  |  | 85d |  |  |
| 18 | 1.2.15 | 楼地面找平层施工 | 15d | 2004-05-22 | 2004-06-05 | 12SS+20d |  |  |  | 20d | 0d |  |
| 19 | 1.2.16 | 楼地面块料面层施工 | 35d | 2004-06-01 | 2004-07-05 | 18SS+10d |  |  |  | 5d | 0d |  |
| 20 | 1.2.17 | 楼地面脚线施工 | 20d | 2004-06-16 | 2004-07-05 | 19SS+15d |  |  |  | 5d | 0d |  |
| 21 | 1.2.18 | 楼地面铺地毯 | 25d | 2004-07-06 | 2004-07-30 | 26SS+35d |  |  |  | 2d |  |  |
| 22 | 1.2.19 | 不锈钢栏河及梯栏杆 | 25d | 2004-06-16 | 2004-07-10 | 19SS+15d |  |  |  | 5d |  |  |
| 23 | 1.2.20 | 水电工程 | 118d | 2004-03-17 | 2004-07-12 | 2SS+2d |  |  |  | 3d |  |  |
| 24 | 1.2.21 | 窗帘盒制安 | 25d | 2004-05-22 | 2004-06-15 | 12SS+20d |  |  |  | 30d |  |  |
| 25 | 1.2.22 | 玻璃饰面 | 25d | 2004-06-21 | 2004-07-15 | 12 |  |  |  | 7d |  |  |
| 26 | 1.2.23 | 油漆工程 | 50d | 2004-06-01 | 2004-07-20 | 12SS+30d |  |  |  | 10d | 0d |  |

| ID | WBS | Task | Duration | Start | Finish | Predecessors | Baseline start | Baseline finish | Baseline duration | Total slack | Free slack |
| --- | --- | --- | --- | --- | --- | --- | --- | --- | --- | --- | --- |
| 27 | 1.3 | **第二施工区（6~15层）** | 125d | 2004-03-20 | 2004-07-22 |  | 2004-03-02 | 2004-03-02 | 1d? | 18d |  |
| 28 | 1.3.1 | 新墙砌筑 | 20d | 2004-03-20 | 2004-04-08 | 2SS+5d |  |  |  | 12d | 0d |
| 29 | 1.3.2 | 墙面抹灰 | 25d | 2004-03-25 | 2004-04-18 | 28SS+5d |  |  |  | 55d | 0d |
| 30 | 1.3.3 | 天棚龙骨 | 55d | 2004-04-04 | 2004-05-28 | 29SS+10d |  |  |  | 10d | 0d |
| 31 | 1.3.4 | 天棚面层施工 | 65d | 2004-04-14 | 2004-06-17 | 30SS+10d |  |  |  | 10d | 0d |
| 32 | 1.3.5 | 墙面瓷砖粘贴施工 | 45d | 2004-04-04 | 2004-05-18 | 29SS+10d |  |  |  | 75d |  |
| 33 | 1.3.6 | 卫生间防水施工 | 40d | 2004-04-09 | 2004-05-18 | 28 |  |  |  | 10d | 0d |
| 34 | 1.3.7 | 楼地面找平层施工 | 35d | 2004-04-29 | 2004-06-02 | 33SS+20d |  |  |  | 10d | 0d |
| 35 | 1.3.8 | 楼地面块料面层施工 | 65d | 2004-05-09 | 2004-07-12 | 34SS+10d |  |  |  | 10d | 0d |
| 36 | 1.3.9 | 楼地面脚线施工 | 30d | 2004-06-18 | 2004-07-17 | 35SS+40d |  |  |  | 15d |  |
| 37 | 1.3.10 | 楼地面铺地毯 | 28d | 2004-06-23 | 2004-07-20 | 35SS+45d |  |  |  | 12d |  |
| 38 | 1.3.11 | 不锈钢栏河及梯栏杆 | 45d | 2004-06-03 | 2004-07-17 | 35SS+25d |  |  |  | 15d |  |
| 39 | 1.3.12 | 水电工程 | 118d | 2004-03-25 | 2004-07-20 | 28SS+5d |  |  |  | 12d |  |
| 40 | 1.3.13 | 油漆工程 | 75d | 2004-05-09 | 2004-07-22 | 31SS+25d |  |  |  | 10d |  |
| 41 | 1.4 | **第三施工区（16~20层）** | 138d | 2004-03-25 | 2004-08-09 |  | 2004-03-02 | 2004-03-02 | 1d? | 0d |  |
| 42 | 1.4.1 | 新墙砌筑 | 12d | 2004-03-25 | 2004-04-05 | 2SS+10d |  |  |  | 0d |  |
| 43 | 1.4.2 | 墙面抹灰 | 20d | 2004-03-30 | 2004-04-18 | 42SS+5d |  |  |  | 0d |  |
| 44 | 1.4.3 | 隔断墙及墙面龙骨施工 | 28d | 2004-04-19 | 2004-05-16 | 43 |  |  |  | 0d |  |
| 45 | 1.4.4 | 天棚龙骨 | 35d | 2004-04-09 | 2004-05-13 | 43SS+10d |  |  |  | 72d | 0d |
| 46 | 1.4.5 | 天棚面层施工 | 28d | 2004-04-24 | 2004-05-21 | 45SS+15d |  |  |  | 72d |  |
| 47 | 1.4.6 | 墙面石材粘贴（干挂）施工 | 40d | 2004-04-19 | 2004-05-28 | 43 |  |  |  | 65d |  |
| 48 | 1.4.7 | 墙面瓷砖粘贴施工 | 25d | 2004-04-19 | 2004-05-13 | 43 |  |  |  | 25d | 0d |
| 49 | 1.4.8 | 软包墙面施工 | 30d | 2004-06-08 | 2004-07-07 | 51SS+25d |  |  |  | 25d |  |
| 50 | 1.4.9 | 木质板材墙面装饰施工 | 55d | 2004-05-17 | 2004-07-10 | 44 |  |  |  | 0d |  |
| 51 | 1.4.10 | 墙面进口立邦漆涂刷施工 | 35d | 2004-05-14 | 2004-06-17 | 48 |  |  |  | 25d | 0d |
| 52 | 1.4.11 | 玻璃隔断墙施工 | 40d | 2004-05-17 | 2004-06-25 | 44 |  |  |  | 37d |  |
| 53 | 1.4.12 | 墙面壁纸施工 | 25d | 2004-06-11 | 2004-07-05 | 50SS+25d |  |  |  | 27d |  |
| 54 | 1.4.13 | 墙面不锈钢饰面 | 15d | 2004-07-06 | 2004-07-20 | 57SS+10d |  |  |  | 12d |  |
| 55 | 1.4.14 | 卫生间防水施工 | 20d | 2004-04-06 | 2004-04-25 | 42 |  |  |  | 98d |  |
| 56 | 1.4.15 | 楼地面找平层施工 | 15d | 2004-06-16 | 2004-06-30 | 50SS+30d |  |  |  | 4d | 0d |
| 57 | 1.4.16 | 楼地面块料面层施工 | 30d | 2004-06-26 | 2004-07-25 | 56SS+10d |  |  |  | 4d | 0d |
| 58 | 1.4.17 | 楼地面脚线施工 | 23d | 2004-07-06 | 2004-07-28 | 57SS+10d |  |  |  | 4d |  |
| 59 | 1.4.18 | 楼地面铺地毯 | 13d | 2004-07-28 | 2004-08-09 | 64SS+50d |  |  |  | 0d |  |
| 60 | 1.4.19 | 不锈钢栏河及梯栏杆 | 22d | 2004-07-06 | 2004-07-27 | 57SS+10d |  |  |  | 5d |  |
| 61 | 1.4.20 | 水电工程 | 115d | 2004-03-30 | 2004-07-22 | 42SS+5d |  |  |  | 10d |  |
| 62 | 1.4.21 | 窗帘盒制安 | 25d | 2004-06-06 | 2004-06-30 | 50SS+20d |  |  |  | 32d |  |
| 63 | 1.4.22 | 玻璃饰面 | 35d | 2004-06-16 | 2004-07-20 | 50SS+30d |  |  |  | 12d |  |
| 64 | 1.4.23 | 油漆工程 | 55d | 2004-06-08 | 2004-08-01 | 50SS+22d |  |  |  | 0d |  |
| 65 | 1.5 | 工程收尾及竣工验收 | 2d | 2004-08-10 | 2004-08-11 | 3, 41, 27 |  |  |  | 0d |  |
